# Butik i Århus

How a schedule from MS Project changed from version to version. A marks actual dates.

## Version 1 (saved 2007-09-13, file Opgave 2.mpp)

| ID | WBS | Task | Duration | Start | Finish | Predecessors | Total float |
| --- | --- | --- | --- | --- | --- | --- | --- |
| 1 | 1 | **Ny butik i Århus** | 28.88d | 2007-09-10 | 2007-10-18 |  | 0d |
| 2 |  | Tegning | 3d | 2007-09-10 | 2007-09-12 |  | 0d |
| 3 | 1.2 | **Fundament** | 8d | 2007-09-13 | 2007-09-24 | 2 | 0d |
| 4 |  | Udgravning | 2d | 2007-09-13 | 2007-09-14 |  | 0d |
| 5 |  | Støbning | 1d | 2007-09-17 | 2007-09-17 | 4 | 0d |
| 6 |  | Afbinding | 5d | 2007-09-18 | 2007-09-24 | 5 | 0d |
| 7 | 1.3 | **Råhus** | 7d | 2007-09-25 | 2007-10-03 | 6 | 0d |
| 8 |  | Bærende konstruktioner | 3d | 2007-09-25 | 2007-09-27 |  | 0d |
| 9 |  | Ydervægge | 2d | 2007-09-28 | 2007-10-01 | 8 | 0d |
| 10 |  | Tag | 2d | 2007-10-02 | 2007-10-03 | 9 | 0d |
| 11 |  | Rejsegilde | 0d | 2007-10-03 | 2007-10-03 | 10 | 0d |
| 12 |  | Taglægning | 2d | 2007-10-04 | 2007-10-05 | 11 | 0d |
| 13 |  | Døre og vinduer | 2d | 2007-10-08 | 2007-10-09 | 12 | 0d |
| 14 |  | Faskine | 2d | 2007-10-10 | 2007-10-11 | 13 | 0d |
| 15 |  | Tagrender | 5h | 2007-10-12 | 2007-10-12 | 14 | 0d |
| 16 |  | Maling udvendigt | 10h | 2007-10-12 | 2007-10-15 | 15 | 0d |
| 17 |  | Gulv | 1d | 2007-10-15 | 2007-10-16 | 16 | 0d |
| 18 |  | Maling indvendigt | 2d | 2007-10-16 | 2007-10-18 | 17 | 0d |
| 19 |  | Indvielse | 0d | 2007-10-18 | 2007-10-18 | 18 | 0d |

## Version 2 (saved 2007-09-13, file Opgave 3A.mpp)

Last finish 2007-10-18 → 2007-10-15 (-3d).

Changed:

| ID | Task | Start | Finish | Duration | Total float | Predecessors |
| --- | --- | --- | --- | --- | --- | --- |
| 1 | **Ny butik i Århus** |  | 2007-10-18 → 2007-10-15 (-3d) | 28.88d → 26d |  |  |
| 7 | **Råhus** |  | 2007-10-03 → 2007-10-01 (-2d) | 7d → 5d |  |  |
| 10 | Tag | 2007-10-02 → 2007-09-28 (-4d) | 2007-10-03 → 2007-10-01 (-2d) |  |  | 9 → 9SS |
| 11 | Rejsegilde | 2007-10-03 → 2007-10-01 (-2d) | 2007-10-03 → 2007-10-01 (-2d) |  |  |  |
| 12 | Taglægning | 2007-10-04 → 2007-10-02 (-2d) | 2007-10-05 → 2007-10-15 (+10d) | 2d → 10d |  |  |
| 13 | Døre og vinduer | 2007-10-08 → 2007-10-02 (-6d) | 2007-10-09 → 2007-10-03 (-6d) |  | 0d → 5.12d | 12 → 12SS |
| 14 | Faskine | 2007-10-10 → 2007-09-17 (-23d) | 2007-10-11 → 2007-09-18 (-23d) |  | 0d → 14.12d | 13 → 4 |
| 15 | Tagrender | 2007-10-12 → 2007-10-02 (-10d) | 2007-10-12 → 2007-10-02 (-10d) |  | 0d → 5.12d | 14 → 14, 13SS |
| 16 | Maling udvendigt | 2007-10-12 → 2007-10-02 (-10d) | 2007-10-15 → 2007-10-03 (-12d) |  | 0d → 5.12d |  |
| 17 | Gulv | 2007-10-15 → 2007-10-03 (-12d) | 2007-10-16 → 2007-10-04 (-12d) |  | 0d → 5.12d |  |
| 18 | Maling indvendigt | 2007-10-16 → 2007-10-12 (-4d) | 2007-10-18 → 2007-10-15 (-3d) |  |  | 17 → 17, 12FF |
| 19 | Indvielse | 2007-10-18 → 2007-10-15 (-3d) | 2007-10-18 → 2007-10-15 (-3d) |  |  |  |

## Version 3 (saved 2007-09-13, file Opgave 4A.mpp)

Last finish 2007-10-15 → 2007-10-16 (+1d).

Changed:

| ID | Task | Start | Finish | Duration | Total float | Predecessors |
| --- | --- | --- | --- | --- | --- | --- |
| 1 | **Ny butik i Århus** |  | 2007-10-15 → 2007-10-16 (+1d) | 26d → 26.25d |  |  |
| 3 | **Fundament** | 2007-09-13 → 2007-09-17 (+4d) |  | 8d → 6d |  | 2 → 2FS+2d |
| 4 | Udgravning | 2007-09-13 → 2007-09-17 (+4d) | 2007-09-14 → 2007-09-18 (+4d) |  |  |  |
| 5 | Støbning | 2007-09-17 → 2007-09-19 (+2d) | 2007-09-17 → 2007-09-19 (+2d) |  |  |  |
| 6 | Afbinding | 2007-09-18 → 2007-09-19 (+1d) |  | 5d → 5ed | 0d → 1.88d |  |
| 7 | **Råhus** |  |  | 5d → 4.25d |  |  |
| 9 | Ydervægge | 2007-09-28 → 2007-09-27 (-1d) |  |  |  | 8 → 8FS-2.5% |
| 10 | Tag | 2007-09-28 → 2007-09-27 (-1d) |  |  |  |  |
| 11 | Rejsegilde |  |  |  |  | 10 → 10, 9 |
| 12 | Taglægning | 2007-10-02 → 2007-10-01 (-1d) |  |  |  |  |
| 13 | Døre og vinduer | 2007-10-02 → 2007-10-01 (-1d) |  |  | 5.12d → 5.75d |  |
| 14 | Faskine | 2007-09-17 → 2007-09-19 (+2d) | 2007-09-18 → 2007-09-20 (+2d) |  | 14.12d → 12.12d |  |
| 15 | Tagrender | 2007-10-02 → 2007-10-01 (-1d) | 2007-10-02 → 2007-10-01 (-1d) |  | 5.12d → 5.75d |  |
| 16 | Maling udvendigt | 2007-10-02 → 2007-10-01 (-1d) |  |  | 5.12d → 5.75d |  |
| 17 | Gulv | 2007-10-03 → 2007-10-02 (-1d) | 2007-10-04 → 2007-10-03 (-1d) |  | 5.12d → 5.75d | 16 → 16FS-5% |
| 18 | Maling indvendigt | 2007-10-12 → 2007-10-11 (-1d) |  |  |  |  |
| 19 | Indvielse | 2007-10-15 → 2007-10-16 (+1d) | 2007-10-15 → 2007-10-16 (+1d) |  |  | 18 → 18FS+1d, 13 |

## Version 4 (saved 2007-09-13, file Opgave 4C.mpp)

Last finish stays 2007-10-16.

Changed:

| ID | Task | Start | Finish | Duration | Total float | Predecessors | Other |
| --- | --- | --- | --- | --- | --- | --- | --- |
| 1 | **Ny butik i Århus** |  |  | 26.25d → 26d |  |  |  |
| 2 | Tegning |  | 2007-09-12 → 2007-09-14 (+2d) |  |  |  | resources none → Arkitekt Arne |
| 3 | **Fundament** | 2007-09-17 → 2007-09-14 (-3d) |  |  |  | 2FS+2d → 2 |  |
| 4 | Udgravning | 2007-09-17 → 2007-09-14 (-3d) |  |  |  |  | resources none → Jord og beton Jette; Gravemaskine |
| 5 | Støbning | 2007-09-19 → 2007-09-18 (-1d) |  |  |  |  | resources none → Jord og beton Jette; Betonblander |
| 7 | **Råhus** | 2007-09-25 → 2007-09-24 (-1d) |  | 4.25d → 4.5d |  |  |  |
| 8 | Bærende konstruktioner | 2007-09-25 → 2007-09-24 (-1d) |  |  |  |  | resources none → Tømrer Tom |
| 9 | Ydervægge |  | 2007-10-01 → 2007-09-28 (-3d) |  |  |  | resources none → Murer Mads |
| 10 | Tag |  |  |  |  |  | resources none → Snedker Susanne |
| 11 | Rejsegilde |  |  |  |  |  | resources none → Arkitekt Arne; Jord og beton Jette; Maler Morten; Murer Mads; Snedker Susanne; Tømrer Tom; VVS Victoria |
| 12 | Taglægning |  |  |  |  |  | resources none → Tømrer Tom |
| 13 | Døre og vinduer |  |  |  | 5.75d → 5.62d |  | resources none → Snedker Susanne |
| 14 | Faskine | 2007-09-19 → 2007-09-18 (-1d) |  |  |  |  | resources none → Jord og beton Jette; Gravemaskine |
| 15 | Tagrender |  |  |  | 5.75d → 5.62d |  | resources none → VVS Victoria |
| 16 | Maling udvendigt |  |  |  | 5.75d → 5.62d |  | resources none → Maler Morten |
| 17 | Gulv |  |  |  | 5.75d → 5.62d |  | resources none → Snedker Susanne |
| 18 | Maling indvendigt |  |  |  |  |  | resources none → Maler Morten |
| 19 | Indvielse |  |  |  |  |  | resources none → Arkitekt Arne; Jord og beton Jette; Maler Morten; Murer Mads; Snedker Susanne; Tømrer Tom; VVS Victoria |

## Version 5 (saved 2007-09-13, file Opgave 6C.mpp)

Last finish stays 2007-10-16.

Changed:

| ID | Task | Start | Finish | Total float | Predecessors |
| --- | --- | --- | --- | --- | --- |
| 14 | Faskine | 2007-09-18 → 2007-09-19 (+1d) | 2007-09-20 → 2007-09-21 (+1d) | 12.12d → 11.12d | 4 → 5, 4 |
| 17 | Gulv | 2007-10-02 → 2007-10-03 (+1d) | 2007-10-03 → 2007-10-04 (+1d) | 5.62d → 4.62d | 16FS-5% → 16FS-5%, 13 |

## Version 6 (saved 2007-09-13, file Opgave 7.mpp)

Last finish 2007-10-16 → 2007-10-18 (+2d). Complete tasks 0 → 16.

Changed:

| ID | Task | Start | Finish | Duration | Complete | Total float | Other |
| --- | --- | --- | --- | --- | --- | --- | --- |
| 1 | **Ny butik i Århus** | 2007-09-10 A | 2007-10-16 → 2007-10-18 A (+2d) | 26d → 28.38d | 0% → 100% | 0d → none | baseline start none → 2007-09-10; baseline finish none → 2007-10-16 |
| 2 | Tegning | 2007-09-10 A | 2007-09-14 A |  | 0% → 100% | 0d → none | baseline start none → 2007-09-10; baseline finish none → 2007-09-14 |
| 3 | **Fundament** | 2007-09-14 A | 2007-09-24 A |  | 0% → 100% | 0d → none | baseline start none → 2007-09-14; baseline finish none → 2007-09-24 |
| 4 | Udgravning | 2007-09-14 A | 2007-09-18 A |  | 0% → 100% | 0d → none | baseline start none → 2007-09-14; baseline finish none → 2007-09-18 |
| 5 | Støbning | 2007-09-18 A | 2007-09-19 A |  | 0% → 100% | 0d → none | baseline start none → 2007-09-18; baseline finish none → 2007-09-19 |
| 6 | Afbinding | 2007-09-19 A | 2007-09-24 A |  | 0% → 100% | 0d → none | baseline start none → 2007-09-19; baseline finish none → 2007-09-24 |
| 7 | **Råhus** | 2007-09-24 A | 2007-10-01 A | 4.5d → 4.88d | 0% → 100% | 0d → none | baseline start none → 2007-09-24; baseline finish none → 2007-10-01 |
| 8 | Bærende konstruktioner | 2007-09-24 A | 2007-09-27 → 2007-09-28 A (+1d) | 3d → 3.5d | 0% → 100% | 0d → none | baseline start none → 2007-09-24; baseline finish none → 2007-09-27 |
| 9 | Ydervægge | 2007-09-27 A | 2007-09-28 → 2007-10-01 A (+3d) |  | 0% → 100% | 0d → none | baseline start none → 2007-09-27; baseline finish none → 2007-09-28 |
| 10 | Tag | 2007-09-27 A | 2007-10-01 A |  | 0% → 100% | 0d → none | baseline start none → 2007-09-27; baseline finish none → 2007-10-01 |
| 11 | Rejsegilde | 2007-10-01 A | 2007-10-01 A |  | 0% → 100% | 0d → none | baseline start none → 2007-10-01; baseline finish none → 2007-10-01 |
| 12 | Taglægning | 2007-10-01 A | 2007-10-15 → 2007-10-17 A (+2d) | 10d → 12d | 0% → 100% | 0d → none | baseline start none → 2007-10-01; baseline finish none → 2007-10-15 |
| 13 | Døre og vinduer | 2007-10-01 A | 2007-10-03 → 2007-10-08 A (+5d) | 2d → 4d | 0% → 100% | 4.5d → none | baseline start none → 2007-10-01; baseline finish none → 2007-10-03 |
| 14 | Faskine | 2007-09-19 A | 2007-09-21 A |  | 0% → 100% | 11.12d → none | baseline start none → 2007-09-19; baseline finish none → 2007-09-21 |
| 15 | Tagrender | 2007-10-01 A | 2007-10-01 → 2007-10-02 A (+1d) |  | 0% → 100% | 5.62d → none | baseline start none → 2007-10-01; baseline finish none → 2007-10-01 |
| 16 | Maling udvendigt | 2007-10-01 → 2007-10-02 A (+1d) | 2007-10-03 A |  | 0% → 100% | 5.62d → none | baseline start none → 2007-10-01; baseline finish none → 2007-10-03 |
| 17 | Gulv | 2007-10-03 → 2007-10-08 A (+5d) | 2007-10-04 → 2007-10-09 A (+5d) |  | 0% → 100% | 4.62d → none | baseline start none → 2007-10-03; baseline finish none → 2007-10-04 |
| 18 | Maling indvendigt | 2007-10-11 → 2007-10-15 A (+4d) | 2007-10-15 → 2007-10-17 A (+2d) |  | 0% → 100% | 0d → none | baseline start none → 2007-10-11; baseline finish none → 2007-10-15 |
| 19 | Indvielse | 2007-10-16 → 2007-10-18 A (+2d) | 2007-10-16 → 2007-10-18 A (+2d) |  | 0% → 100% | 0d → none | baseline start none → 2007-10-16; baseline finish none → 2007-10-16 |
